# CSS Training Manual

Schedule from MS Project, 2007-07-09 to 2007-09-04, costs in $.
Book Development
Our Global Company
Office Manager on vacation 7/10/07.

## Calendars

- Our Global Company: Mon-Fri 08:00-12:00, 13:00-17:00; Sat-Sun off. Exceptions (off unless hours are given): 2007-09-03 (Labor Day).

## Resources

| Resource | Group | Rate | Cost per use |
| --- | --- | --- | --- |
| Editor 1 | Internal | 17 |  |
| Printer 1 | External | 8 |  |
| Publisher 1 | Internal | 48.08 |  |
| Staff Assistant 1 | Internal | 10 |  |
| Staff Assistant 2 | Internal | 10 |  |
| Subject Matter Expert 1 | External | 30 |  |
| Subject Matter Expert 2 | External | 30 |  |
| Writer 1 | Internal | 45 |  |
| Account Rep 1 | External |  | 500 |
| Artist 1 | External |  | 625 |
| Glossy paper | External | 150 |  |

## Schedule

| ID | WBS | Task | Type | Duration | Start | Finish | Predecessors | Total slack | Free slack | Constraint | Deadline | Resources | Work | Cost |
| --- | --- | --- | --- | --- | --- | --- | --- | --- | --- | --- | --- | --- | --- | --- |
| 1 | 1 | Start Book | milestone | 0d | 2007-07-09 | 2007-07-09 |  | -6d | 0d | start no earlier than 2007-07-09 |  |  |  |  |
| 2 | 2 | **Research Phase** |  | 2d | 2007-07-09 | 2007-07-10 |  | -6d | 0d |  | 2007-07-02 |  | 32h | 1,160 |
| 3 | 2.1 | Interview Subject Matter Expert |  | 2d | 2007-07-09 | 2007-07-10 | 1 | -6d | 0d |  |  | Writer 1 | 16h | 720 |
| 4 | 2.2 | Search the Web |  | 1d | 2007-07-09 | 2007-07-10 | 3SS+2% | -5.4d | 0d |  |  | Staff Assistant 1; Writer 1 | 16h | 440 |
| 5 | 3 | **Outline Phase** |  | 7d | 2007-07-10 | 2007-07-19 |  | -2.15d | 0d |  |  |  | 64h | 2,492.31 |
| 6 | 3.1 | Create Outline |  | 5d | 2007-07-10 | 2007-07-17 | 4 | -2.15d | 0d |  |  | Writer 1 | 40h | 1,800 |
| 7 | 3.2 | Present to Publisher |  | 0.5d | 2007-07-17 | 2007-07-17 | 6 | -2.15d | 0d |  |  | Publisher 1; Writer 1 | 8h | 372.31 |
| 8 | 3.3 | Revise Outline |  | 1d | 2007-07-17 | 2007-07-18 | 7 | -2.15d | 0d |  |  | Staff Assistant 1 | 8h | 80 |
| 9 | 3.4 | Review with Subject Matter Expert |  | 0.5d | 2007-07-18 | 2007-07-19 | 8 | 17.35d | 0d |  |  | Subject Matter Expert 1; Subject Matter Expert 2 | 8h | 240 |
| 10 | 3.5 | Outline Complete | milestone | 0d | 2007-07-19 | 2007-07-19 | 9 | 17.35d |  |  |  |  |  |  |
| 11 | 4 | **Development Phase** |  | 21d | 2007-07-18 | 2007-08-16 |  | -2.15d | 0d |  |  |  | 200h | 9,000 |
| 12 | 4.1 | Write Content |  | 20d | 2007-07-18 | 2007-08-15 | 10FF, 8 | -2.15d | 0d |  |  | Writer 1 | 160h | 7,200 |
| 13 | 4.2 | Add Graphics |  | 1w | 2007-08-09 | 2007-08-16 | 12FF+1d | -2.15d | 0d |  |  | Writer 1 | 40h | 1,800 |
| 14 | 4.3 | Development Complete | milestone | 0d | 2007-08-16 | 2007-08-16 | 13 | -2.15d | 0d |  |  |  |  |  |
| 15 | 5 | **Edit Phase** |  | 5d | 2007-08-16 | 2007-08-23 |  | -2.15d | 0d |  |  |  | 120h | 3,080 |
| 16 | 5.1 | Check grammar, spelling, and proofread |  | 1w | 2007-08-16 | 2007-08-23 | 14 | -2.15d | 0d | start no earlier than 2007-08-14 |  | Editor 1 | 40h | 680 |
| 17 | 5.2 | Check for technical accuracy |  | 1w | 2007-08-16 | 2007-08-23 | 16FF | -2.15d | 0d |  |  | Subject Matter Expert 1; Subject Matter Expert 2 | 80h | 2,400 |
| 18 | 6 | **Review Phase** |  | 1.25d | 2007-08-23 | 2007-08-27 |  | -2.15d | 0d |  |  |  | 20h | 564 |
| 19 | 6.1 | Approve editing changes |  | 1d | 2007-08-23 | 2007-08-24 | 17 | -2.15d | 0d |  |  | Writer 1; Staff Assistant 2 | 16h | 440 |
| 20 | 6.2 | Meet with editor |  | 0.25d | 2007-08-24 | 2007-08-27 | 19 | -2.15d | 0d |  |  | Writer 1; Editor 1 | 4h | 124 |
| 21 | 7 | **Print Phase** |  | 5d | 2007-08-27 | 2007-09-04 |  | -2.15d | 0d |  |  |  | 64h | 1,448 |
| 22 | 7.1 | Print proof |  | 1d | 2007-08-27 | 2007-08-28 | 20 | -2.15d | 0d |  |  | Printer 1 | 8h | 64 |
| 23 | 7.2 | Review proof |  | 3d | 2007-08-28 | 2007-08-31 | 22 | -2.15d | 0d |  |  | Writer 1; Staff Assistant 1 | 48h | 1,320 |
| 24 | 7.3 | Print final |  | 1d | 2007-08-31 | 2007-09-04 | 23 | -2.15d | 0d |  |  | Printer 1 | 8h | 64 |
| 25 | 7.4 | Book Complete | milestone | 0d | 2007-08-29 | 2007-08-29 | 24 | -2.15d | 0d | finish no later than 2007-08-29 |  |  |  |  |

Notes:
- 24: $150 for special paper.
- 25: CEO requires completion by 8/29/07.
